# PROYECTO DE GRADO

Schedule from MS Project, 2021-01-18 to 2021-02-15, costs in $.

## Calendars

- Estándar: Mon-Thu 07:00-12:00, 13:00-16:30; Fri 07:00-12:00, 13:30-17:00; Sat 07:00-13:00; Sun off.

## Resources

| Resource | Group | Unit | Rate |
| --- | --- | --- | --- |
| Cuadrilla ofic-ayud tipo aa | HH |  | 6868 |
| Volqueta 5.5 m3 viaje |  |  |  |
| Compresor con martillo |  |  |  |
| Transporte de Material de Base |  |  |  |
| Material de base (gradación 2) |  | m3 | 58759.3 |
| Rodillo compactador |  |  |  |
| Cemento gris |  | kg | 477.69 |
| Transporte de acero |  |  |  |
| Acero refuerzo 420 Mpa |  |  | 4230.68 |
| Alambre Negro Para Amarre |  |  | 2000 |
| Cizalla manual de 90 cm. |  |  | 3000 |
| tranporte de cemento |  |  |  |
| Barras de transferencia de carga (1'') |  | kg | 29791.2 |
| Aditivo Acelerante de Fraguado |  | kg | 12268.8 |
| Barras de unión de 1/2´´ |  | kg | 1710.07 |
| Cintilla De Poliuretano (Sikarod) (Pavimentos De Concreto Hidráulico) |  | ml | 1134.51 |
| Sello de silicona o sellador autonivelante |  | ml | 4727.79 |
| Antisol blanco (presentación 20 kg) |  | kg | 7982.85 |
| Concreto hidráulico para pavimento MR-43 |  | m3 | 549414 |
| Aspersor manual |  |  |  |
| Compresor (barrido y soplado) |  |  |  |
| Cortadora de pavimento, Máxima profundidad de corte: 160 mm. Capacidad de disco: desde 12´´ hasta 18´´ de diámetro. Peso operacional: 135 kg, 13.5 hp de potencia |  |  |  |
| Formaleta metálica (concreto hidráulico) |  |  |  |
| Regla vibratoria, de longitud de 3 a 5 m, motor de 3600 rpm, potencia 6 HP |  |  |  |
| Vibrador de concreto, Motor de 3 hp a 18.000 rpm Mangueras de 4 mt |  |  |  |
| Mezcladora 9¨c/op |  |  |  |
| Concreto 3000 PSI en obra |  | M2 | 87835.9 |
| Antisol rojo |  | kl | 2974.36 |
| Acero refuerzo 60000 PSI |  | kl | 9956.65 |
| Rieles de pavimento |  |  |  |
| Mortero 1:3 Para Anillos |  | m3 | 9118.12 |
| Concreto Resistencia 14 (Mpa) |  | m3 | 29087 |
| Formaleta (gaviones, juntas de bordillos, juntas de cunetas, muros, concretos clase D,E, F y G) |  | m2 | 2021.59 |
| Impermeabilizante para concreto |  | kg | 11912.5 |
| Oficial |  |  | 53343.1 |
| Esferas reflectivas |  | kg | 5385.14 |
| Disolvente para pintura Trafico (acrílico) |  | gal | 30029.1 |
| Pintura acrílica pura para tráfico |  | gal | 79944.1 |
| recursos |  |  |  |
| Cuadrilla ofic-ayud tipo aa DEMOLICION | HH |  | 66867.8 |
| Cuadrilla ofic-ayud tipo aa PAV | HH |  | 35650 |
| Cuadrilla ofic-ayud tipo aa CUNE |  |  | 28657.6 |
| Cuadrilla ofic-ayud tipo aa BORDI |  |  | 10030.2 |

## Schedule

| ID | WBS | Task | Duration | Start | Finish | Predecessors | Total slack | Resources | Work | Cost |
| --- | --- | --- | --- | --- | --- | --- | --- | --- | --- | --- |
| 2 | 1 | **MEJORAMIENTO DE LAS VÍAS PRINCIPALES TRAMO AVENIDA LIBERTADOR, AVENIDA FERROCARRIL Y AVENIDA DEL RÍO, PARA ASÍ GARANTIZAR MEJOR MOVILIDAD Y DISMINUCIÓN EN LA TASA DE ACCIDENTALIDAD EN LA CIUDAD SANTA MARTA** | 25d | 2021-01-18 | 2021-02-15 |  | 0d |  | 152h | 69,297,362.26 |
| 3 | 1.1 | **ACTIVIDAD** | 6d | 2021-01-18 | 2021-01-25 |  | 0d |  |  | 600,000 |
| 4 | 1.1.1 | ACTIVIDAD PRELIMINAR | 6d | 2021-01-18 | 2021-01-25 |  | 0d | recursos [0.1%] |  | 600,000 |
| 5 | 1.2 | **DEMOLICIÓN** | 3d | 2021-01-25 | 2021-01-27 |  | 0d |  | 24h | 2,018,649.24 |
| 6 | 1.2.1 | DEMOLICIÓN DE PAVIMENTOS RÍGIDOS | 3d | 2021-01-25 | 2021-01-27 | 4 | 0d | Volqueta 5.5 m3 viaje [0.1%]; Compresor con martillo [0.1%]; Cuadrilla ofic-ayud tipo aa DEMOLICION | 24h | 2,018,649.24 |
| 7 | 1.3 | **EXCAVACIÓN** | 3d | 2021-01-28 | 2021-02-01 |  | 0d |  | 24h | 1,751,146.24 |
| 8 | 1.3.1 | EXCAVACIÓN EN MATERIAL COMÚN DE PRÉSTAMOS | 3d | 2021-01-28 | 2021-02-01 | 6 | 0d | Volqueta 5.5 m3 viaje [0.1%]; Cuadrilla ofic-ayud tipo aa DEMOLICION | 24h | 1,751,146.24 |
| 9 | 1.4 | **BASE** | 2d | 2021-02-01 | 2021-02-02 |  | 0d |  | 16h | 4,488,654.79 |
| 10 | 1.4.1 | BASE TRATADA CON CEMENTO RESISTENCIA R-5.2 (NO INCLUYE SUMINISTRO DE CEMENTO) | 2d | 2021-02-01 | 2021-02-02 | 8 | 0d | Cuadrilla ofic-ayud tipo aa; Transporte de Material de Base [0.1%]; Material de base (gradación 2) [62.18 m3]; Rodillo compactador [0.1%] | 16h | 4,488,654.79 |
| 11 | 1.5 | **CEMENTO** | 1d | 2021-02-03 | 2021-02-03 |  | 0d |  |  | 760,104.6 |
| 12 | 1.5.1 | CEMENTO HIDRAULICO PARA BASE TRATADA CON CEMENTO | 1d | 2021-02-03 | 2021-02-03 | 10 | 0d | Cemento gris [1340 kg]; tranporte de cemento [0.1%] |  | 760,104.6 |
| 13 | 1.6 | **Acero** | 2d | 2021-02-03 | 2021-02-05 |  | 0d |  | 16h | 1,653,408.52 |
| 14 | 1.6.1 | Acero de Refuerzo Fy 4200 Mpa. | 2d | 2021-02-03 | 2021-02-05 | 12 | 0d | Cuadrilla ofic-ayud tipo aa; Transporte de acero [0.1%]; Acero refuerzo 420 Mpa [33033%]; Alambre Negro Para Amarre [1000%]; Cizalla manual de 90 cm. [200%] | 16h | 1,653,408.52 |
| 15 | 1.7 | **Pavimento** | 3d | 2021-02-05 | 2021-02-09 |  | 0d |  | 24h | 37,054,098.02 |
| 16 | 1.7.1 | Pavimento de concreto hidráulico de fraguado rapido (Fast Track) | 3d | 2021-02-05 | 2021-02-09 | 14 | 0d | Barras de transferencia de carga (1'') [55.91 kg]; Aditivo Acelerante de Fraguado [120 kg]; Barras de unión de 1/2´´ [274.32 kg]; Cintilla De Poliuretano (Sikarod) (Pavimentos De Concreto Hidráulico) [45 ml]; Sello de silicona o sellador autonivelante [90 ml]; Antisol blanco (presentación 20 kg) [140 kg]; Concreto hidráulico para pavimento MR-43 [56.25 m3]; Aspersor manual [0.1%]; Compresor (barrido y soplado) [0.1%]; Cortadora de pavimento, Máxima profundidad de corte: 160 mm. Capacidad de disco: desde 12´´ hasta 18´´ de diámetro. Peso operacional: 135 kg, 13.5 hp de potencia [0.1%]; Formaleta metálica (concreto hidráulico) [0.1%]; Regla vibratoria, de longitud de 3 a 5 m, motor de 3600 rpm, potencia 6 HP [0.1%]; Vibrador de concreto, Motor de 3 hp a 18.000 rpm Mangueras de 4 mt [0.1%]; Mezcladora 9¨c/op [0.1%]; Cuadrilla ofic-ayud tipo aa PAV | 24h | 37,054,098.02 |
| 17 | 1.8 | **CUNETA** | 3d | 2021-02-05 | 2021-02-09 |  | 0d |  | 24h | 3,091,970.7 |
| 18 | 1.8.1 | CUNETA | 3d | 2021-02-05 | 2021-02-09 | 16SS | 0d | Concreto 3000 PSI en obra [23.63 M2]; Antisol rojo [45 kl]; Acero refuerzo 420 Mpa [4500%]; Mezcladora 9¨c/op [0.1%]; Rieles de pavimento [0.1%]; Cuadrilla ofic-ayud tipo aa CUNE | 24h | 3,091,970.7 |
| 19 | 1.9 | **Bordillo** | 1d | 2021-02-11 | 2021-02-12 |  | 0d |  | 8h | 106,869.01 |
| 20 | 1.9.1 | Bordillo de Concreto Vaciado In Situ; incluye la preparacion de la superficie de apoyo | 1d | 2021-02-11 | 2021-02-12 | 18FS+2d | 0d | Mortero 1:3 Para Anillos [0.2 m3]; Concreto Resistencia 14 (Mpa) [0.54 m3]; Formaleta (gaviones, juntas de bordillos, juntas de cunetas, muros, concretos clase D,E, F y G) [4.5 m2]; Cuadrilla ofic-ayud tipo aa BORDI | 8h | 106,869.01 |
| 21 | 1.10 | **Impermeabilizante** | 1d | 2021-02-12 | 2021-02-13 |  | 0d |  | 8h | 1,379,743.36 |
| 22 | 1.10.1 | Impermeabilizante para Concreto | 1d | 2021-02-12 | 2021-02-13 | 20 | 0d | Oficial; Impermeabilizante para concreto [80 kg] | 8h | 1,379,743.36 |
| 23 | 1.11 | **Marca Vial** | 1d | 2021-02-15 | 2021-02-15 |  | 0d |  | 8h | 401,018.87 |
| 24 | 1.11.1 | Marca Vial con Pintura en Frío. | 1d | 2021-02-15 | 2021-02-15 | 22 | 0d | Cuadrilla ofic-ayud tipo aa; Esferas reflectivas [3 kg]; Disolvente para pintura Trafico (acrílico) [3 gal]; Pintura acrílica pura para tráfico [3 gal] | 8h | 401,018.87 |
